# Planning 17066 PALTEFORME ARMED

Schedule from MS Project, 2026-08-31 to 2026-11-10, 7 hours a day.
CHU de Clermont-Ferrand

## Calendars

- Standard: Mon-Fri 09:00-12:00, 14:00-18:00; Sat-Sun off. Exceptions (off unless hours are given): 2025-01-01 to 2035-01-01 (Jour de l'An, recurring), 2025-05-01 to 2035-05-01 (Fête du travail, recurring), 2025-05-08 to 2035-05-08 (Armistice 1945, recurring), 2025-07-14 to 2035-07-14 (Fête Nationale, recurring), 2025-08-15 to 2035-08-15 (Assomption, recurring), 2025-11-01 to 2035-11-01 (Toussaint, recurring), 2025-11-11 to 2035-11-11 (Armistice, recurring), 2025-12-22 to 2036-01-05 (Noël, recurring).

## Resources

| Resource |
| --- |
| DTES |
| BDM |
| Bureau marché |
| Maria |
| Cédric |
| Nat |
| TVX |
| Service |
| CT |
| CHU |
| Platrerie Peinture |

## Schedule

| ID | WBS | Task | Duration | Start | Finish | Predecessors | Baseline start | Baseline finish | Baseline duration | Total slack | Free slack | Constraint | Resources | Work |
| --- | --- | --- | --- | --- | --- | --- | --- | --- | --- | --- | --- | --- | --- | --- |
| 1 | 1 | **Lot 1 - PLATRERIE PEINTURE MACONNERIE** | 44d | 2026-08-31 | 2026-10-29 |  | 2025-07-23 | 2025-10-20 | 53d | 3d |  |  |  | 42h |
| 2 | 1.1 | PROTECTION DE CHANTIER VERTICALE RIGIDE | 2d | 2026-08-31 | 2026-09-01 |  |  |  |  | 54d | 0d | start no earlier than 2026-08-31 |  |  |
| 3 | 1.2 | PROTECTION DE CHANTIER PVC SOUPLE AU SOL | 2d | 2026-08-31 | 2026-09-01 | 2SS |  |  |  | 54d |  |  |  |  |
| 4 | 1.3 | CURAGE INTERIEUR | 5d | 2026-09-03 | 2026-09-09 | 34 | 2025-10-28 | 2025-10-30 | 3d | 0d |  | start no earlier than 2025-10-28 |  |  |
| 5 | 1.4 | DALLE BETON EXTERIEURE | 4d | 2026-09-03 | 2026-09-08 | 38 | 2025-10-28 | 2025-12-11 | 32d | 47d | 0d | start no earlier than 2025-10-15 | TVX | 28h |
| 6 | 1.5 | CARROTAGES | 2d | 2026-09-03 | 2026-09-04 | 5SS | 2025-11-07 | 2026-01-05 | 35d | 47d |  |  | TVX | 14h |
| 7 | 1.6 | DOUBLAGE ISOLANT CLOISON PLAQUES DE PLATRE | 6d | 2026-09-14 | 2026-09-21 | 31 |  |  |  | 0d |  |  |  |  |
| 8 | 1.7 | CLOISON PLAQUES DE PLATRE TOUTE HAUTEUR EP 98MM EI 60 | 6d | 2026-09-22 | 2026-09-29 | 7 |  |  |  | 0d |  |  |  |  |
| 9 | 1.8 | POSE DES HUISSERIES | 2d | 2026-09-22 | 2026-09-23 | 8SS |  |  |  | 38d |  |  |  |  |
| 10 | 1.9 | DEMOLITION CLOISON SECHE POUR CREATION D’OUVERTURE | 5d | 2026-09-17 | 2026-09-23 | 38FS+10d |  |  |  | 37d | 0d |  |  |  |
| 11 | 1.10 | POSE DES HUISSERIES 2241+2241A | 2d | 2026-09-18 | 2026-09-21 | 10SS+1d |  |  |  | 40d |  |  |  |  |
| 12 | 1.11 | PEINTURE MURALE SATINEE PHASE AQUEUSE | 15d | 2026-09-30 | 2026-10-20 | 8 |  |  |  | 0d |  |  |  |  |
| 13 | 1.12 | PEINTURE SATINEE PHASE AQUEUSE SUR BOIS PEINT INTERIEUR | 15d | 2026-09-30 | 2026-10-20 | 12SS |  |  |  | 16d | 0d |  |  |  |
| 14 | 1.13 | PEINTURE ISOTHERMIQUE SUR RADIATEURS ET TUYAUTERIES | 7d | 2026-09-30 | 2026-10-08 | 12SS |  |  |  | 23d |  |  |  |  |
| 15 | 1.14 | RACCORD ENDUIT ET PEINTURE | 3d | 2026-10-21 | 2026-10-23 | 12 |  |  |  | 12d |  |  |  |  |
| 16 | 1.15 | FAUX PLAFOND | 7d | 2026-10-21 | 2026-10-29 | 12 |  |  |  | 3d | 0d |  |  |  |
| 17 | 2 | **LOT 2 MENUISERIES INTERIEURES EXTERIEURES** | 49d | 2026-08-31 | 2026-11-05 |  |  |  |  | 3d |  |  |  |  |
| 18 | 2.1 | DEPOSE ENLEVEMENT STOCKAGE PAILLASSES | 3d | 2026-08-31 | 2026-09-02 |  |  |  |  | 42d | 0d | start no earlier than 2026-08-31 |  |  |
| 19 | 2.2 | DEPOSE BLOCS PORTES | 1d | 2026-08-31 | 2026-08-31 | 18SS |  |  |  | 55d |  |  |  |  |
| 20 | 2.3 | DEPOSE VANTAUX FENETRES+QUINCAILLERIE | 2d | 2026-08-31 | 2026-09-01 | 18SS |  |  |  | 42d | 0d |  |  |  |
| 21 | 2.4 | BLOC PORTE HUISSERIE BOIS, EI 30 - 2241 + 2241A | 1d | 2026-09-24 | 2026-09-24 | 10 |  |  |  | 37d |  |  |  |  |
| 22 | 2.5 | BLOC PORTE HUISSERIE BOIS, EI 30 - 2245 +2246A+2244A | 3d | 2026-09-30 | 2026-10-02 | 8 |  |  |  | 31d |  |  |  |  |
| 23 | 2.6 | CHASSIS VITRES 2244A | 2d | 2026-09-30 | 2026-10-01 | 8 |  |  |  | 32d |  |  |  |  |
| 24 | 2.7 | FERME PORTE QUINCAILLERIE | 3d | 2026-10-21 | 2026-10-23 | 13 |  |  |  | 12d |  |  |  |  |
| 25 | 2.8 | PLINTHES A PEINDRE 10CM | 2d | 2026-09-23 | 2026-09-24 | 8FS-5d |  |  |  | 37d |  |  |  |  |
| 26 | 2.9 | HABILLAGE PORTES GRILLAGEES EXTERIEURES | 2d | 2026-09-16 | 2026-09-17 | 20FS+10d |  |  |  | 42d |  |  |  |  |
| 27 | 2.10 | INSTALLATION PAILLASSES | 5d | 2026-10-30 | 2026-11-05 | 16 |  |  |  | 7d |  |  |  |  |

| ID | WBS | Task | Duration | Start | Finish | Predecessors | Baseline start | Baseline finish | Baseline duration | Total slack | Free slack | Constraint | Resources | Work |
| --- | --- | --- | --- | --- | --- | --- | --- | --- | --- | --- | --- | --- | --- | --- |
| 28 | 3 | **LOT 3 REVETEMENT DE SOLS** | 11d | 2026-09-03 | 2026-09-17 |  |  |  |  | 5d |  |  |  |  |
| 29 | 3.1 | ARRACHAGE DE SOLS 2240 | 3d | 2026-09-03 | 2026-09-07 | 18 |  |  |  | 46d | 0d |  |  |  |
| 30 | 3.2 | RAGREAGE+SOL | 4d | 2026-09-08 | 2026-09-11 | 29 |  |  |  | 46d |  |  |  |  |
| 31 | 3.3 | RAGREAGE SOL 2246-2246A-2245 | 2d | 2026-09-10 | 2026-09-11 | 4 |  |  |  | 0d |  |  |  |  |
| 32 | 3.4 | PVC LES HOMOGENE | 4d | 2026-09-14 | 2026-09-17 | 31 |  |  |  | 42d |  |  |  |  |
| 33 | 4 | **LOT 4 CVC PLOMBERIE** | 47d | 2026-08-31 | 2026-11-03 |  |  |  |  | 0d |  |  |  |  |
| 34 | 4.1 | DEPOSE EQUIPEMENTS DANS TOUS LES LOCAUX | 3d | 2026-08-31 | 2026-09-02 |  |  |  |  | 0d |  | start no earlier than 2026-08-31 |  |  |
| 35 | 4.2 | PASSAGE RESEAUX | 25d | 2026-09-03 | 2026-10-07 | 34 |  |  |  | 28d |  |  |  |  |
| 36 | 4.3 | INSTALLATION EQUIPEMENT ET TERMINAUX | 15d | 2026-10-14 | 2026-11-03 | 12FS-5d |  |  |  | 5d |  |  |  |  |
| 37 | 5 | **LOT 5 ELECTRICITE CFO** | 47d | 2026-08-31 | 2026-11-03 |  |  |  |  | 9d |  |  |  |  |
| 38 | 5.1 | DEPOSE EQUIPEMENTS DANS TOUS LES LOCAUX | 3d | 2026-08-31 | 2026-09-02 | 34SS |  |  |  | 28d | 0d | start no earlier than 2025-11-24 |  |  |
| 39 | 5.2 | CABLAGE | 25d | 2026-09-03 | 2026-10-07 | 38 |  |  |  | 28d |  |  |  |  |
| 40 | 5.3 | INSTALLATION EQUIPEMENT ET TERMINAUX | 15d | 2026-10-14 | 2026-11-03 | 12FS-5d |  |  |  | 5d |  |  |  |  |
| 41 | 6 | **LOT 6 ELECTRICITE CFA VDI SSI** | 47d | 2026-08-31 | 2026-11-03 |  |  |  |  | 9d |  |  |  |  |
| 42 | 6.1 | DEPOSE EQUIPEMENTS DANS TOUS LES LOCAUX | 3d | 2026-08-31 | 2026-09-02 | 34SS |  |  |  | 28d | 0d | start no earlier than 2025-11-24 |  |  |
| 43 | 6.2 | CABLAGE | 25d | 2026-09-03 | 2026-10-07 | 42 |  |  |  | 28d |  |  |  |  |
| 44 | 6.3 | INSTALLATION EQUIPEMENT ET TERMINAUX | 15d | 2026-10-14 | 2026-11-03 | 12FS-5d |  |  |  | 5d |  |  |  |  |
| 45 | 7 | **LOT 7 FLUIDES LABORATOIRES** | 47d | 2026-08-31 | 2026-11-03 |  |  |  |  | 5d |  |  |  |  |
| 46 | 7.1 | DEPOSE EQUIPEMENTS | 3d | 2026-08-31 | 2026-09-02 |  |  |  |  | 24d | 0d |  |  |  |
| 47 | 7.2 | PASSAGE RESEAUX | 25d | 2026-09-03 | 2026-10-07 | 46 |  |  |  | 24d |  |  |  |  |
| 48 | 7.3 | INSTALLATION EQUIPEMENT ET TERMINAUX | 15d | 2026-10-14 | 2026-11-03 | 12FS-5d |  |  |  | 0d |  |  |  |  |
| 49 | 8 | OPR | 3d | 2026-11-04 | 2026-11-06 | 48 | 2026-01-15 | 2026-02-11 | 20d | 0d |  | start no earlier than 2026-02-23 | DTES | 21h |
| 50 | 9 | Contrôle technique | 5d | 2026-11-04 | 2026-11-10 | 49SS | 2026-02-12 | 2026-02-18 | 5d | 0d |  |  | CT | 35h |
